# Planning_150109_RG_V001

Schedule from MS Project, 2009-01-01 to 2009-04-14, 7 hours a day.

## Calendars

- Standard: Mon-Fri 09:00-12:00, 14:00-18:00; Sat-Sun off.

## Resources

| Resource |
| --- |
| R Gallet |
| C. Drancourt |
| A. Dalmaz |
| S. Cap |
| N. Geffroy |
| ? |
| Guillaume |
| Entreprises extérieures |
| Maine Circuits Imprimés |
| Personnel à définir |

## Schedule

| ID | WBS | Task | Duration | Start | Finish | Predecessors | Total slack | Free slack | Constraint | Resources | Work |
| --- | --- | --- | --- | --- | --- | --- | --- | --- | --- | --- | --- |
| 1 | 1 | **Projet montage tests cartes 32x48** | 74d? | 2009-01-01 | 2009-04-14 |  | 0d |  |  | R Gallet | 4881.8h |
| 2 | 1.1 | **Electronique** | 67d? | 2009-01-01 | 2009-04-03 |  | 0d |  |  | C. Drancourt | 3369.8h |
| 3 | 1.1.1 | **Cartes 32x48** | 66d? | 2009-01-02 | 2009-04-03 |  | 0d |  |  | A. Dalmaz | 896h |
| 4 | 1.1.1.1 | Conception | 16d? | 2009-01-02 | 2009-01-23 |  | 0d |  | start no earlier than 2009-01-02 | A. Dalmaz | 112h |
| 5 | 1.1.1.2 | Fabrication des PCB | 20d | 2009-01-26 | 2009-02-20 | 4 | 0d |  | start no earlier than 2009-01-23 | Maine Circuits Imprimés | 140h |
| 6 | 1.1.1.3 | Approvisionnement des circuits Hardroc | 9d | 2009-02-09 | 2009-02-19 |  | 1d |  | start no earlier than 2009-02-09 |  |  |
| 7 | 1.1.1.4 | Cablage | 20d | 2009-02-23 | 2009-03-20 | 5, 6 | 0d |  |  | Entreprises extérieures | 140h |
| 8 | 1.1.1.5 | Tests électriques | 5d | 2009-03-23 | 2009-03-27 | 7 | 0d |  |  | C. Drancourt [20%]; A. Dalmaz | 42h |
| 9 | 1.1.1.6 | Pose du bulk | 5d | 2009-03-30 | 2009-04-03 | 8 | 0d |  |  |  |  |
| 11 | 1.1.2 | **Cartes Diff** | 55d? | 2009-01-01 | 2009-03-18 |  | 12d |  |  | S. Cap | 753.2h |
| 12 | 1.1.2.1 | Conception | 17d? | 2009-01-01 | 2009-01-23 |  | 12d | 0d | start no earlier than 2009-01-01 | S. Cap | 119h |
| 13 | 1.1.2.2 | Fabrication PCB | 20d | 2009-01-26 | 2009-02-20 | 12 | 12d | 0d | finish no earlier than 2009-01-21 | Maine Circuits Imprimés | 140h |
| 14 | 1.1.2.3 | Cablage | 10d? | 2009-02-23 | 2009-03-06 | 13 | 12d | 0d |  | Entreprises extérieures | 70h |
| 15 | 1.1.2.4 | Tests électriques | 8d | 2009-03-09 | 2009-03-18 | 14 | 12d |  | start no earlier than 2009-02-19 | S. Cap [70%] | 39.2h |
| 17 | 1.1.3 | **Cartes interfaces** | 41d? | 2009-01-15 | 2009-03-12 |  | 16d |  |  | S. Cap | 625.8h |
| 18 | 1.1.3.1 | Conception | 17d? | 2009-02-18 | 2009-03-12 |  | 16d |  | finish no earlier than 2009-03-12 | S. Cap | 119h |
| 19 | 1.1.3.2 | Fabrication PCB | 15d | 2009-01-15 | 2009-02-04 |  | 25d | 0d |  | Maine Circuits Imprimés | 105h |
| 20 | 1.1.3.3 | Cablage | 15d? | 2009-02-05 | 2009-02-25 | 19 | 25d | 0d |  | Entreprises extérieures | 105h |
| 21 | 1.1.3.4 | Tests électriques | 2d | 2009-02-26 | 2009-02-27 | 20 | 25d |  | start no earlier than 2009-02-19 | S. Cap [70%] | 9.8h |
| 23 | 1.1.4 | **Cartes bouchons** | 41d? | 2009-01-15 | 2009-03-12 |  | 16d |  |  | A. Dalmaz | 625.8h |
| 24 | 1.1.4.1 | Conception | 17d? | 2009-02-18 | 2009-03-12 |  | 16d |  | finish no earlier than 2009-03-12 | A. Dalmaz | 119h |
| 25 | 1.1.4.2 | Fabrication PCB | 15d | 2009-01-15 | 2009-02-04 |  | 25.6d | 0d |  | Maine Circuits Imprimés | 105h |
| 26 | 1.1.4.3 | Cablage | 15d? | 2009-02-05 | 2009-02-25 | 25 | 25.6d | 0d |  | Entreprises extérieures | 105h |
| 27 | 1.1.4.4 | Tests électriques | 1.4d | 2009-02-26 | 2009-02-27 | 26 | 25.6d |  | start no earlier than 2009-02-19 | A. Dalmaz | 9.8h |

| ID | WBS | Task | Duration | Start | Finish | Predecessors | Total slack | Free slack | Constraint | Resources | Work |
| --- | --- | --- | --- | --- | --- | --- | --- | --- | --- | --- | --- |
| 29 | 1.2 | **Mécanique** | 38d? | 2009-01-02 | 2009-02-24 |  | 28d |  |  | N. Geffroy | 994h |
| 30 | 1.2.1 | **Boite de test** | 22d? | 2009-01-02 | 2009-02-02 |  | 44d |  |  |  | 161h |
| 31 | 1.2.1.1 | Design | 20d? | 2009-01-02 | 2009-01-29 |  | 44d | 0d | finish no earlier than 2009-01-29 | N. Geffroy | 140h |
| 32 | 1.2.1.2 | Fabrication à l'atelier | 1d? | 2009-01-30 | 2009-01-30 | 31 | 44d | 0d |  | Personnel à définir | 7h |
| 33 | 1.2.1.3 | Fabrications extérieures | 1d? | 2009-01-30 | 2009-01-30 | 31 | 44d | 0d |  | Entreprises extérieures | 7h |
| 34 | 1.2.1.4 | Montage | 1d? | 2009-02-02 | 2009-02-02 | 32, 33 | 44d |  |  | Personnel à définir | 7h |
| 35 | 1.2.2 | approvisionnements divers | 15d? | 2009-01-15 | 2009-02-04 |  | 42d |  |  | N. Geffroy | 105h |
| 36 | 1.2.3 | **Bôite de transport** | 33d? | 2009-01-09 | 2009-02-24 |  | 28d |  |  | N. Geffroy | 462h |
| 37 | 1.2.3.1 | Design | 15d? | 2009-01-09 | 2009-01-29 |  | 28d | 0d | finish no earlier than 2009-01-29 | N. Geffroy | 105h |
| 38 | 1.2.3.2 | Fabrication à l'atelier | 15d | 2009-01-30 | 2009-02-19 | 37 | 28d | 0d |  | Personnel à définir | 105h |
| 39 | 1.2.3.3 | Montage | 3d? | 2009-02-20 | 2009-02-24 | 38 | 28d |  |  | Personnel à définir | 21h |
| 42 | 1.3 | Intégration | 7d? | 2009-04-06 | 2009-04-14 | 29, 2 | 0d |  |  |  |  |
